# 2008 Schedule Template Rev. 3

Schedule from MS Project, 2008-06-09 to 2008-10-06.
Jefferson Lab

## Calendars

- Standard: Mon-Fri 08:00-12:00, 13:00-17:00; Sat-Sun off.

## Resources

| Resource |
| --- |
| RADCON |
| Alignment Group |
| Hall-C tech's |
| ACC tech's |
| Hall C Tech's |
| Cryo Target Tech's |
| Hall C Tech's / ESH&Q |
| Experimenters |
| Hall C Tech's / RADCO |
| Hall C Tech's / RADCON |
| Hall C Tech's / Experim. |
| Target Group / Experimenters |
| Target Group / Experim. |
| Alignment Group / Hall C Tech's |
| Align. Group / Hall C Tech's |
| Users/Hall C tech's |
| RADCON tech's |
| Survey group |
| Eric Christy / Paul Hood |
| Hall C Tech's / Hamlet |
| Design/Eng group |
| Lockwood / Hall C Tech's |
| Lockwood |
| Contractor |
| Hall C Tech's / Electri. |
| Experimenters/ H C Tech's |
| Miscellaneous |
| Target Group / Cryo group |

## Schedule

| ID | Task | Duration | Start | Finish | Total slack | Constraint | Resources | Work | Text1 | Text7 | Text2 | Text11 | Text12 | Text16 |
| --- | --- | --- | --- | --- | --- | --- | --- | --- | --- | --- | --- | --- | --- | --- |
| 1 | 2008 Jun. to Oct. Hall-C SANE installation and HHS/HES Prep. | 86d | 2008-06-09 | 2008-10-06 | 0d | start no earlier than 2008-06-09 |  |  |  |  |  |  |  |  |
| 2 | Meeting with Hall C Staff, RADCON, ALIGN, ACC, EH&S, Target group | 0.1d | 2008-06-09 | 2008-06-09 | 85.9d | start no earlier than 2008-06-09 | Miscellaneous | 0.8h |  |  |  |  |  |  |
| 3 | Beam line and target Radiation cool down | 6d | 2008-06-09 | 2008-06-16 | 80d | start no earlier than 2008-06-09 | RADCON | 48h |  |  |  |  |  |  |
| 4 | Prepare safety / work documentation for this schedule | 6d | 2008-06-09 | 2008-06-16 | 80d | start no earlier than 2008-06-09 | Hall C Tech's | 48h |  |  |  |  |  |  |
| 5 | GEP decommissioning June 9 to July 3 | 13d | 2008-06-09 | 2008-06-25 | 73d | start no earlier than 2008-06-09 |  |  |  |  |  |  |  |  |
| 6 | Clear truck ramp, move in areal platforms, tools and equipment into Hall | 1d | 2008-06-09 | 2008-06-09 | 85d |  | Hall C Tech's | 8h | ITHA Req'd | 1 |  |  |  |  |
| 7 | RADCON support required | 1d | 2008-06-09 | 2008-06-09 | 85d | start no earlier than 2008-06-09 | RADCON | 8h | ITHA Req'd | 0 | Req'd |  |  |  |
| 8 | Crane HES dipole sections to beam left side | 1d | 2008-06-17 | 2008-06-17 | 79d | start no earlier than 2008-06-17 | Hall C Tech's | 8h | THA Req'd | 1 |  |  |  |  |
| 9 | Move HMS to 45 deg. | 1d | 2008-06-17 | 2008-06-17 | 79d | start no earlier than 2008-06-17 | Design/Eng group | 8h | ITHA Req'd | 2 |  | Req'd |  |  |
| 10 | Crane BIG CAL close to wall (to clear space) | 1d | 2008-06-17 | 2008-06-17 | 79d | start no earlier than 2008-06-17 | Hall C Tech's / Experim. | 8h | ITHA Req'd | 2 |  |  | C-08-005-L |  |
| 11 | Crane 45' JLG and 45' Groove to downstream beam line | 1d | 2008-06-20 | 2008-06-20 | 76d | start no earlier than 2008-06-20 | Hall C Tech's | 8h | ITHA Req'd | 2 |  |  | C-08-014-L |  |
| 12 | Disassemble beam line from pivot to dump and store in Hall | 2d | 2008-06-23 | 2008-06-24 | 74d | finish no earlier than 2008-06-24 | Hall C Tech's | 16h | THA Req'd | 2 |  | Req'd | L Req'd |  |
| 13 | RADCON support required | 2d | 2008-06-23 | 2008-06-24 | 74d | finish no earlier than 2008-06-24 | RADCON | 16h | ITHA Req'd | 0 | Req'd |  |  |  |
| 14 | Install and commission Secondary emission monitor | 8d | 2008-07-07 | 2008-07-16 | 58d | start no earlier than 2008-07-07 |  |  |  |  |  |  |  |  |
| 15 | Disconnect and remove up stream girder | 1d | 2008-08-11 | 2008-08-11 | 40d | start no earlier than 2008-08-11 | ACC tech's | 8h | ITHA Req'd | 1 | Req'd |  |  |  |
| 16 | RADCON support required | 1d | 2008-08-11 | 2008-08-11 | 40d | start no earlier than 2008-08-11 | RADCON | 8h | ITHA Req'd | 0 | Req'd |  |  |  |
| 17 | Mount SEM onto new girder and bolt girder assembly into position | 1d | 2008-08-12 | 2008-08-12 | 39d | start no earlier than 2008-08-12 | ACC tech's | 8h | ITHA Req'd | 2 | Req'd |  |  |  |
| 18 | Connect girder beam line and cables | 2d | 2008-08-13 | 2008-08-14 | 37d | finish no earlier than 2008-08-14 | ACC tech's | 16h | ITHA Req'd | 1 | Req'd |  |  |  |
| 19 | Align and secure girder | 1d | 2008-08-15 | 2008-08-15 | 36d | start no earlier than 2008-08-15 | Alignment Group | 8h | ITHA Req'd | 2 | Req'd |  |  |  |
| 20 | FPP removal and standard HMS detector reinstallation | 16d | 2008-06-16 | 2008-07-07 | 65d | start no earlier than 2008-06-16 |  |  |  |  |  |  |  |  |
| 21 | Move all 4 wire chamber boxes from storage Bld to Hall C HMS side | 1d | 2008-06-16 | 2008-06-16 | 80d | start no earlier than 2008-06-16 |  |  | ITHA Req'd | 0 |  |  |  |  |
| 22 | Crane 45' JLG's into position | 1d | 2008-06-17 | 2008-06-17 | 79d | finish no earlier than 2008-06-17 | Hall C Tech's | 8h | ITHA Req'd | 2 |  |  | C-08-014-L |  |
| 23 | Crane HMS shield house wall sections down and secure to frame | 1d | 2008-06-18 | 2008-06-18 | 78d | start no earlier than 2008-06-18 | Hall C Tech's / Experim. | 8h | THA Req'd | 2 |  | Req'd |  |  |
| 24 | Disconnect and remove FPP Electronic racks | 1d | 2008-06-19 | 2008-06-19 | 77d | start no earlier than 2008-06-19 | Hall C Tech's / Experim. | 8h | ITA Req'd | 1 |  | Req'd |  |  |
| 25 | RADCON support required | 1d | 2008-06-19 | 2008-06-19 | 77d | finish no earlier than 2008-06-19 | RADCON | 8h | ITHA Req'd | 0 | Req'd |  |  |  |
| 26 | Disconnect and remove HMS trigger electronics | 1d | 2008-06-19 | 2008-06-19 | 77d | start no earlier than 2008-06-19 | Experimenters | 8h | ITHA Req'd | 1 |  | Req'd |  |  |
| 27 | RADCON support required | 1d | 2008-06-19 | 2008-06-19 | 77d | start no earlier than 2008-06-19 | RADCON tech's | 8h | ITHA Req'd | 0 | Req'd |  |  |  |
| 28 | Remove small scintillator assembly in front of exit window | 1d | 2008-06-20 | 2008-06-20 | 76d | start no earlier than 2008-06-20 | Hall C Tech's / Experim. | 8h | ITHA Req'd | 1 |  |  |  |  |
| 29 | Position and connect installation fixtures 67502-00019 | 2d | 2008-06-23 | 2008-06-24 | 74d | start no earlier than 2008-06-23 | Hall C Tech's | 16h | THA Req'd | 2 |  |  |  |  |
| 30 | Disconnect and remove wire chambers | 2d | 2008-06-23 | 2008-06-24 | 74d | start no earlier than 2008-06-23 | Hall C Tech's / Experim. | 16h | THA Req'd | 2 |  | Req'd |  |  |
| 31 | Place chambers in shipping crate and cover | 2d | 2008-06-23 | 2008-06-24 | 74d | start no earlier than 2008-06-23 | Hall C Tech's / Experim. | 16h | THA Req'd | 2 |  | Req'd |  |  |
| 32 | RADCON support required | 2d | 2008-06-23 | 2008-06-24 | 74d | start no earlier than 2008-06-23 | RADCON tech's | 16h | ITHA Req'd | 0 |  |  |  |  |
| 33 | Set up and align installation fixtures for CH2 blocks | 2d | 2008-06-25 | 2008-06-26 | 72d | start no earlier than 2008-06-25 | Hall C Tech's | 16h | ITHA Req'd | 1 |  |  |  |  |
| 34 | RADCON support required | 2d | 2008-06-25 | 2008-06-26 | 72d | start no earlier than 2008-06-25 | RADCON | 16h | ITHA Req'd | 0 | Req'd |  |  |  |
| 35 | Unbolt and slide out all CH2 blocks then crane out storage | 2d | 2008-06-25 | 2008-06-26 | 72d | start no earlier than 2008-06-25 | Hall C Tech's / Experim. | 16h | THA Req'd | 2 |  | Req'd |  |  |
| 36 | RADCON support required | 2d | 2008-06-25 | 2008-06-26 | 72d | start no earlier than 2008-06-25 | RADCON tech's | 16h | ITHA Req'd | 0 |  |  |  |  |
| 37 | Remove installation fixture | 1d | 2008-06-26 | 2008-06-26 | 72d | start no earlier than 2008-06-26 | Hall C Tech's | 8h | ITHA Req'd | 1 |  |  |  |  |
| 38 | Unbolt and remove wire chamber ALU support frame | 1d | 2008-06-26 | 2008-06-26 | 72d | start no earlier than 2008-06-26 | Hall C Tech's | 8h | ITHA Req'd | 1 |  |  |  |  |
| 39 | Restore position for first hodoscope plane | 1d | 2008-06-26 | 2008-06-26 | 72d | start no earlier than 2008-06-26 | Hall C Tech's / Experim. | 8h | ITHA Req'd | 1 |  |  |  |  |
| 40 | Reinstall Cerenkov detector | 1d | 2008-06-26 | 2008-06-26 | 72d | start no earlier than 2008-06-26 | Hall C Tech's | 8h | THA Req'd | 2 |  |  |  |  |
| 41 | Align Cerenkov detector and secure | 1d | 2008-06-27 | 2008-06-27 | 71d | start no earlier than 2008-06-27 | Hall C Tech's / Experim. | 8h | ITHA Req'd | 0 |  |  |  |  |
| 42 | Reinstall aerogell chamber | 1d | 2008-06-30 | 2008-06-30 | 70d | start no earlier than 2008-06-30 | Hall C Tech's / Hamlet | 8h | THA Req'd | 2 |  | Req'd |  |  |
| 43 | Install 2nd hodoscopes plane | 1d | 2008-06-30 | 2008-06-30 | 70d | start no earlier than 2008-06-30 | Hall C Tech's / Hamlet | 8h | THA Req'd | 1 |  |  |  |  |
| 44 | HMS detector hut light bulbs | 1d | 2008-07-01 | 2008-07-01 | 69d | start no earlier than 2008-07-01 | Hall C Tech's | 8h | ITHA Req'd | 1 |  |  |  |  |
| 45 | BIG CAL glass anneal | 54d | 2008-06-17 | 2008-08-29 | 26d | finish no earlier than 2008-08-29 |  |  |  |  |  |  |  |  |
| 46 | Uncover and prepare lead glass detector stack | 2d | 2008-06-17 | 2008-06-18 | 78d | start no earlier than 2008-06-17 | Experimenters/ H C Tech's | 16h |  | 1 |  | Req'd |  |  |
| 47 | Crane and install and connect UV lights | 1d | 2008-06-18 | 2008-06-18 | 78d | start no earlier than 2008-06-18 | Experimenters/ H C Tech's | 8h |  | 2 |  | Req'd |  |  |
| 48 | Reposition UV lights during anneal as required | 50d | 2008-06-18 | 2008-08-26 | 29d | start no earlier than 2008-06-18 | Experimenters | 400h |  | 1 |  | Req'd |  |  |
| 49 | Disconnect UV lights and crane of BIG CAL | 1d | 2008-08-26 | 2008-08-26 | 29d | start no earlier than 2008-08-26 | Experimenters/ H C Tech's | 8h |  | 1 |  | Req'd |  |  |
| 50 | Cover and seal lead glass stack | 3d | 2008-08-27 | 2008-08-29 | 26d | finish no earlier than 2008-08-29 | Experimenters | 24h |  | 1 |  | Req'd |  |  |
| 51 | Cryo Target disassembly and removal (from Dave Meekins) | 17d | 2008-06-09 | 2008-07-01 | 69d | finish no earlier than 2008-07-01 | Cryo Target Tech's | 136h |  |  |  | 63 |  |  |
| 52 | Warm up Cryo Target an vent scatting chamber | 2d | 2008-06-09 | 2008-06-10 | 84d | start no earlier than 2008-06-09 | Target Group / Experim. | 16h |  | 2 |  | 63 | MCC-PR-06-006 |  |
| 53 | Target Radiation cool down period | 5d | 2008-06-10 | 2008-06-16 | 80d | finish no earlier than 2008-06-16 | RADCON | 40h |  |  |  |  |  |  |
| 54 | Install pivot extensions and railing | 1d | 2008-06-17 | 2008-06-17 | 79d | start no earlier than 2008-06-17 | Hall C Tech's | 8h | THA Req'd | 2 |  |  |  |  |
| 55 | RADCON support required | 1d | 2008-06-17 | 2008-06-17 | 79d | start no earlier than 2008-06-17 | RADCON | 8h | ITHA Req'd | 1 |  | 63 |  |  |
| 56 | Remove scatting chamber windows | 1d | 2008-06-18 | 2008-06-18 | 78d | start no earlier than 2008-06-18 | Cryo Target Tech's | 8h | ITHA Req'd | 1 |  | 63 |  |  |
| 57 | RADCON support required | 1d | 2008-06-18 | 2008-06-18 | 78d | start no earlier than 2008-06-18 | RADCON | 8h | ITHA Req'd | 1 |  | 63 |  |  |
| 58 | Post run survey of target cells | 2d | 2008-06-19 | 2008-06-20 | 76d | start no earlier than 2008-06-19 | Alignment Group | 16h | ITHA Req'd | 1 |  | 63 |  |  |
| 59 | Crane in and place Groove 45' areal platform in place (beam left) | 1d | 2008-06-23 | 2008-06-23 | 75d | start no earlier than 2008-06-23 | Hall C Tech's | 8h | ITHA Req'd | 2 |  |  | C-08-014-L | 1 |
| 60 | Place 60' JLG (beam right) | 1d | 2008-06-23 | 2008-06-23 | 75d | start no earlier than 2008-06-23 | Hall C Tech's | 8h | ITHA Req'd | 2 |  |  | C-08-015-L |  |
| 61 | With Cryo group support un-sting target valve box from distribution can | 1d | 2008-06-23 | 2008-06-23 | 75d | start no earlier than 2008-06-23 | Target Group / Cryo group | 8h | ITHA Req'd | 1 |  | 63 |  |  |
| 62 | Disconnect plumbing and electronics from top of target | 1d | 2008-06-24 | 2008-06-24 | 74d | start no earlier than 2008-06-24 | Cryo Target Tech's | 8h | ITHA Req'd | 2 |  | 63 |  |  |
| 63 | Disconnect the refrigeration transfer lines and store on top of cable tray | 1d | 2008-06-25 | 2008-06-25 | 73d | start no earlier than 2008-06-25 | Cryo Target Tech's | 8h | ITHA Req'd | 1 |  | 63 |  |  |
| 64 | Tie back the plumbing and electrical lines for target | 1d | 2008-06-25 | 2008-06-25 | 73d | start no earlier than 2008-06-25 | Cryo Target Tech's | 8h | ITHA Req'd | 1 |  | 63 |  |  |
| 65 | Use lifting fixture and crane to remove target from pivot | 1d | 2008-06-26 | 2008-06-26 | 72d | start no earlier than 2008-06-26 | Cryo Target Tech's | 8h | ITHA Req'd | 2 |  | 63 |  |  |
| 66 | Disconnect cells and cell blocks and transfer them to the EEL Rad area. | 1d | 2008-06-27 | 2008-06-27 | 71d | start no earlier than 2008-06-27 | Cryo Target Tech's | 8h | ITHA Req'd | 1 |  | 63 |  |  |
| 67 | RADCON support required | 1d | 2008-06-26 | 2008-06-26 | 72d | start no earlier than 2008-06-26 | RADCON | 8h | ITHA Req'd | 1 |  |  |  |  |
| 68 | Place target on forklift and transfer it to EEL target group area | 1d | 2008-06-30 | 2008-06-30 | 70d | start no earlier than 2008-06-30 | Cryo Target Tech's | 8h | ITHA Req'd | 1 |  | 63 |  |  |
| 69 | Polarized Target installation and commissioning | 52d | 2008-07-15 | 2008-09-24 | 8d | start no earlier than 2008-07-15 | Cryo Target Tech's | 416h |  |  |  |  |  |  |
| 70 | Transport target equipment deck, pivot and upper ALU deck to Hall C | 2d | 2008-07-08 | 2008-07-09 | 63d | start no earlier than 2008-07-08 | Hall C Tech's | 16h | ITHA Req'd | 1 |  |  |  |  |

| ID | Task | Duration | Start | Finish | Total slack | Constraint | Resources | Work | Text1 | Text7 | Text11 | Text8 | Text2 | Text12 |
| --- | --- | --- | --- | --- | --- | --- | --- | --- | --- | --- | --- | --- | --- | --- |
| 71 | Relocate signal cables between shield hut and pivot to clear platform install. | 2d | 2008-07-10 | 2008-07-11 | 61d | start no earlier than 2008-07-10 | Hall C Tech's / Experim. | 16h | THA Req'd | 2 | Req'd |  |  |  |
| 72 | Layout and bolt equipment deck support legs to the floor | 1d | 2008-07-14 | 2008-07-14 | 60d | start no earlier than 2008-07-14 | Hall C Tech's | 8h | ITHA Req'd | 1 |  |  |  |  |
| 73 | Crane in and bolt deck onto support legs | 1d | 2008-07-14 | 2008-07-14 | 60d | start no earlier than 2008-07-14 | Hall C Tech's | 8h | THA Req'd | 2 |  |  |  |  |
| 74 | Weld end flanges to the pivot deck | 1d | 2008-07-15 | 2008-07-15 | 59d | start no earlier than 2008-07-15 | Hall C Tech's | 8h | ITHA Req'd | 1 |  | Req'd |  |  |
| 75 | RADCON support required | 1d | 2008-07-15 | 2008-07-15 | 59d | start no earlier than 2008-07-15 | RADCON | 8h | ITHA Req'd | 1 |  |  |  |  |
| 76 | Install staircase, weld to deck then bolt to floor | 1d | 2008-07-15 | 2008-07-15 | 59d | start no earlier than 2008-07-15 | Hall C Tech's | 8h | THA Req'd | 2 |  | Req'd |  |  |
| 77 | Install scattering chamber base on pivot | 1d | 2008-07-16 | 2008-07-16 | 58d | start no earlier than 2008-07-16 | Cryo Target Tech's | 8h | ITHA Req'd | 1 |  |  |  |  |
| 78 | Crane in scattering chamber and bolt to base | 1d | 2008-07-16 | 2008-07-16 | 58d | start no earlier than 2008-07-16 | Cryo Target Tech's | 8h | THA Req'd | 1 | Req'd |  |  |  |
| 79 | Place LHE dewer and electronics racks onto equipment deck | 2d | 2008-07-17 | 2008-07-18 | 56d | start no earlier than 2008-07-17 | Hall C Tech's | 16h | ITHA Req'd | 1 |  |  |  |  |
| 80 | Install target control systems | 11d | 2008-07-18 | 2008-08-01 | 46d | start no earlier than 2008-07-18 | Cryo Target Tech's | 88h | ITHA Req'd | 1 |  |  |  |  |
| 81 | Place target into chamber | 1d | 2008-07-21 | 2008-07-21 | 55d | start no earlier than 2008-07-21 | Cryo Target Tech's | 8h | ITHA Req'd | 2 | Req'd |  |  |  |
| 82 | Connect to vacuum system | 3d? | 2008-07-22 | 2008-07-24 | 52d | start no earlier than 2008-07-22 | Cryo Target Tech's | 24h | ITHA Req'd | 1 | Req'd |  |  |  |
| 83 | Connect cryogenic system, U-tubes etc. | 1d | 2008-07-24 | 2008-07-24 | 52d | start no earlier than 2008-07-24 | Target Group / Cryo group | 8h | ITHA Req'd | 2 |  |  | Req'd |  |
| 84 | Pump out scattering chamber and leak check | 4d | 2008-07-23 | 2008-07-28 | 50d | finish no earlier than 2008-07-28 | Cryo Target Tech's | 32h | ITHA Req'd | 2 | Req'd |  |  |  |
| 85 | Target test cool down | 6d? | 2008-09-23 | 2008-09-30 | 4d | finish no earlier than 2008-09-30 | Cryo Target Tech's | 48h | ITHA Req'd | 3 |  |  |  | TOSP Req'd |
| 86 | G-0 Magnet move from Hall C to long term storage (52 tons) | 22d | 2008-07-07 | 2008-08-05 | 44d | start no earlier than 2008-07-07 |  |  |  |  |  |  |  |  |
| 87 | Move HMS to large angle to max floor space | 1d | 2008-07-07 | 2008-07-07 | 65d | start no earlier than 2008-07-07 | Design/Eng group | 8h | ITHA Req'd | 2 | Req'd |  |  |  |
| 88 | Clear floor space, move beam line and RAD parts to a secure location | 1d | 2008-07-07 | 2008-07-07 | 65d | start no earlier than 2008-07-07 | Hall C Tech's / RADCON | 8h | ITHA Req'd | 1 |  |  |  |  |
| 89 | RADCON support required | 1d | 2008-07-07 | 2008-07-07 | 65d | start no earlier than 2008-07-07 | RADCON | 8h | ITHA Req'd | 0 |  |  |  |  |
| 90 | Move HKS magnets and FW close to the wall | 1d | 2008-07-08 | 2008-07-08 | 64d | start no earlier than 2008-07-08 | Hall C Tech's | 8h | THA Req'd | 2 |  |  |  |  |
| 91 | Assure BIG CAL and cable train are safe | 1d | 2008-07-09 | 2008-07-09 | 63d | start no earlier than 2008-07-09 | Hall C Tech's | 8h | ITHA Req'd | 1 |  |  |  |  |
| 92 | Move G-0 magnet into position and secure | 1d | 2008-07-09 | 2008-07-09 | 63d | start no earlier than 2008-07-09 | Hall C Tech's | 8h | ITHA Req'd | 1 |  |  |  |  |
| 93 | Remove 22" lead pipe, pack into box and move to lead storage Bld. | 1d | 2008-07-09 | 2008-07-09 | 63d | start no earlier than 2008-07-09 | Hall C Tech's | 8h | ITHA Req'd | 2 |  |  |  | C-08-003-L |
| 94 | RADCON support required | 1d | 2008-07-09 | 2008-07-09 | 63d | start no earlier than 2008-07-09 | RADCON | 8h | ITHA Req'd | 0 |  |  |  | C-08-001-L |
| 95 | Remove downstream end cap and lay onto cribbing | 1d | 2008-07-07 | 2008-07-07 | 65d | start no earlier than 2008-07-07 | Hall C Tech's | 8h | ITHA Req'd | 2 |  |  |  | L Req'd |
| 96 | RADCON support required | 2d | 2008-07-09 | 2008-07-10 | 62d | finish no earlier than 2008-07-10 | RADCON | 16h | ITHA Req'd | 0 |  |  |  | C-08-002-L |
| 97 | Remove upstream end cap and lay onto cribbing | 1d | 2008-07-09 | 2008-07-09 | 63d | start no earlier than 2008-07-09 | Hall C Tech's | 8h | ITHA Req'd | 2 |  |  |  | L Req'd |
| 98 | RADCON support required | 2d | 2008-07-09 | 2008-07-10 | 62d | finish no earlier than 2008-07-10 | RADCON | 16h | ITHA Req'd | 0 |  |  |  |  |
| 99 | Unbolt lead, pack into containers and move lead storage Bld. | 2d | 2008-07-09 | 2008-07-10 | 62d | finish no earlier than 2008-07-10 | Hall C Tech's | 16h | ITHA Req'd | 1 |  |  |  |  |
| 100 | RADCON support required | 1d | 2008-07-10 | 2008-07-10 | 62d | start no earlier than 2008-07-10 | RADCON | 8h | ITHA Req'd | 0 |  |  |  |  |
| 101 | Remove all 8 titanium windows and place into storage box | 1d | 2008-06-10 | 2008-06-10 | 84d | start no earlier than 2008-06-10 | Hall C Tech's | 8h | ITHA Req'd | 0 |  |  |  |  |
| 102 | RADCON support required | 1d | 2008-07-11 | 2008-07-11 | 61d | start no earlier than 2008-07-11 | RADCON | 8h | ITHA Req'd | 0 |  |  |  |  |
| 103 | Bolt both end caps together, seal and move to lead storage Bld. | 1d | 2008-07-11 | 2008-07-11 | 61d | start no earlier than 2008-07-11 | Hall C Tech's | 8h | THA Req'd | 2 |  |  |  |  |
| 104 | RADCON support required | 1d | 2008-07-11 | 2008-07-11 | 61d | start no earlier than 2008-07-11 | RADCON | 8h | ITHA Req'd | 0 |  |  |  |  |
| 105 | Install shipping frame onto magnet, torque bolts and seal gaps | 3d | 2008-07-15 | 2008-07-17 | 57d | finish no earlier than 2008-07-17 | Hall C Tech's | 24h | ITHA Req'd | 2 |  |  |  | C-08-016-L |
| 106 | Truck cribbing mats and rails into Hall and lay out for position 1 | 2d | 2008-07-21 | 2008-07-22 | 54d | finish no earlier than 2008-07-22 | Lockwood / Hall C Tech's | 16h | ITHA Req'd | 1 |  |  |  |  |
| 107 | Move 2 hydraulic towers, pump, H beam and swivel in and setup | 1d | 2008-07-23 | 2008-07-23 | 53d | start no earlier than 2008-07-23 | Lockwood / Hall C Tech's | 8h | THA Req'd | 2 |  |  |  |  |
| 108 | Lineup towers, connect magnet to swivel and takeout slack | 1d | 2008-07-24 | 2008-07-24 | 52d | start no earlier than 2008-07-24 | Lockwood | 8h | ITHA Req'd | 1 |  |  |  |  |
| 109 | Unbolt magnet from base, lift, rotate and move to the Hall center | 1d | 2008-07-24 | 2008-07-24 | 52d | start no earlier than 2008-07-24 | Lockwood | 8h | ITHA Req'd | 2 |  |  |  | C-08-016-L |
| 110 | Set magnet on cribbing, disconnect and remove hydraulic towers. | 1d | 2008-07-25 | 2008-07-25 | 51d | start no earlier than 2008-07-25 | Lockwood | 8h | ITHA Req'd | 2 |  |  |  | C-08-016-L |
| 111 | Move cribbing mats and rails to position 2 | 1d | 2008-07-28 | 2008-07-28 | 50d | start no earlier than 2008-07-28 | Lockwood | 8h | ITHA Req'd | 1 |  |  |  |  |
| 112 | Set up 2 pairs of hydraulic towers with H beams | 1d | 2008-07-28 | 2008-07-28 | 50d | start no earlier than 2008-07-28 | Lockwood | 8h | ITHA Req'd | 2 |  |  |  | C-08-016-L |
| 113 | Lift and rotate magnet 90 derg. then onto rollers and secure | 1d | 2008-07-29 | 2008-07-29 | 49d | start no earlier than 2008-07-29 | Lockwood | 8h | ITHA Req'd | 2 |  |  |  | C-08-016-L |
| 114 | Pull magnet up the truck ramp and into position for loading | 1d | 2008-07-29 | 2008-07-29 | 49d | start no earlier than 2008-07-29 | Lockwood | 8h | ITHA Req'd | 2 |  |  |  | C-08-016-L |
| 115 | Load magnet onto trailer, secure and move lead storage Bld. | 1d | 2008-07-30 | 2008-07-30 | 48d | start no earlier than 2008-07-30 | Lockwood | 8h | ITHA Req'd | 2 |  |  |  | C-08-016-L |
| 116 | RADCON support required | 1d | 2008-07-30 | 2008-07-30 | 48d | start no earlier than 2008-07-30 | RADCON | 8h | ITHA Req'd | 0 |  |  |  |  |
| 117 | Unload magnet and roll into lead storage Bld. | 1d | 2008-07-30 | 2008-07-30 | 48d | start no earlier than 2008-07-30 | Lockwood | 8h | ITHA Req'd | 2 |  |  |  | C-08-016-L |
| 118 | RADCON support required | 1d | 2008-07-30 | 2008-07-30 | 48d | start no earlier than 2008-07-30 | RADCON | 8h | ITHA Req'd | 0 |  |  |  |  |
| 119 | Remove all Lockwood equipment from Hall C | 1d | 2008-07-30 | 2008-07-30 | 48d | start no earlier than 2008-07-30 | Lockwood / Hall C Tech's | 8h | ITHA Req'd | 1 |  |  |  |  |
| 120 | Shrink-wrap G-0 magnet | 1d | 2008-08-01 | 2008-08-01 | 46d | start no earlier than 2008-08-01 | Contractor | 8h | ITHA Req'd | 1 |  |  |  |  |
| 121 | Setup N2 flow from CHL through magnet | 2d | 2008-08-04 | 2008-08-05 | 44d | finish no earlier than 2008-08-05 | Hall C Tech's | 16h | ITHA Req'd | 1 |  |  | Req'd |  |
| 122 | HES / HKS preparation (concrete, magnet assembly etc) | 23d | 2008-08-06 | 2008-09-05 | 21d | finish no earlier than 2008-09-05 |  |  |  |  |  |  |  |  |
| 123 | Drill and tap for hoist rings, then place 7/8" steel under new HES base | 2d | 2008-08-06 | 2008-08-07 | 42d | start no earlier than 2008-08-06 | Hall C Tech's | 16h | ITHA Req'd | 1 |  |  |  |  |
| 124 | Assemble HES magnets base with hilman rollers and hydraulic system | 2d | 2008-08-07 | 2008-08-08 | 41d | finish no earlier than 2008-08-08 | Hall C Tech's | 16h | THA Req'd | 2 |  |  |  |  |
| 125 | Place lower dipole half in position and bolt down | 1d | 2008-08-11 | 2008-08-11 | 40d | start no earlier than 2008-08-11 | Hall C Tech's | 8h | ITHA Req'd | 2 |  |  |  |  |
| 126 | Move upper dipole half on top and torque down | 1d | 2008-08-12 | 2008-08-12 | 39d | start no earlier than 2008-08-12 | Hall C Tech's | 8h | ITHA Req'd | 2 |  |  |  |  |
| 127 | Crane Q1 into position next to dipole, align and torque down | 1d | 2008-08-12 | 2008-08-12 | 39d | start no earlier than 2008-08-12 | Hall C Tech's | 8h | ITHA Req'd | 2 |  |  |  |  |
| 128 | Crane Q2 into position next to dipole, align and torque down | 1d | 2008-08-13 | 2008-08-13 | 38d | start no earlier than 2008-08-13 | Hall C Tech's | 8h | ITHA Req'd | 2 |  |  |  |  |
| 129 | Connect vacuum chambers and leak check | 4d | 2008-08-14 | 2008-08-19 | 34d | finish no earlier than 2008-08-19 | Hall C Tech's | 32h | ITHA Req'd | 1 |  |  |  |  |
| 130 | Fiducialize magnet assembly | 2d | 2008-08-20 | 2008-08-21 | 32d | finish no earlier than 2008-08-21 | Alignment Group | 16h | ITHA Req'd | 1 |  |  | Req'd |  |
| 131 | Layout of 9.5" concrete pad extension for new location of the HKS dipole | 1d | 2008-08-22 | 2008-08-22 | 31d | start no earlier than 2008-08-22 | Alignment Group | 8h | ITHA Req'd | 1 |  |  | Req'd |  |
| 132 | Roll HES magnet assembly and HKS dipole close to the wall to clear space | 1d? | 2008-08-22 | 2008-08-22 | 31d | start no earlier than 2008-08-22 | Hall C Tech's | 8h | ITHA Req'd | 1 |  |  |  |  |
| 133 | Brake open and remove concrete over the SOS rail section | 2d | 2008-08-25 | 2008-08-26 | 29d | start no earlier than 2008-08-25 | Hall C Tech's | 16h | ITHA Req'd | 1 |  |  |  |  |
| 134 | Unbolt and remove SOS rail section and transport to bone yard | 1d | 2008-08-27 | 2008-08-27 | 28d | start no earlier than 2008-08-27 | Hall C Tech's | 8h | THA Req'd | 2 |  |  |  |  |
| 135 | RADCON support required | 1d | 2008-08-27 | 2008-08-27 | 28d | start no earlier than 2008-08-27 | RADCON | 8h | ITHA Req'd | 0 |  |  | Req'd |  |
| 136 | Remove all bolts and nuts from the SOS rail base plate | 1d | 2008-08-27 | 2008-08-27 | 28d | start no earlier than 2008-08-27 | Hall C Tech's | 8h | ITHA Req'd | 0 |  |  |  |  |
| 137 | Place plastic sheeting over the base plate, then temporary cove gap | 1d | 2008-08-27 | 2008-08-27 | 28d | start no earlier than 2008-08-27 | Hall C Tech's | 8h | ITHA Req'd | 0 |  |  |  |  |
| 138 | Build concrete forms as marked for new HKS dipole position and place rebar | 4d | 2008-08-28 | 2008-09-02 | 24d | finish no earlier than 2008-09-02 | Contractor | 32h | THA Req'd | 1 |  |  |  |  |
| 139 | Fill SOS rail base gap with concrete and level | 1d | 2008-09-04 | 2008-09-04 | 22d | start no earlier than 2008-09-04 | Contractor | 8h | ITHA Req'd | 1 |  |  |  |  |
| 140 | Pore concrete into HKS extension forms, level and finish | 2d | 2008-09-04 | 2008-09-05 | 21d | start no earlier than 2008-09-04 | Contractor | 16h | THA Req'd | 2 |  |  |  |  |

| ID | Task | Duration | Start | Finish | Total slack | Constraint | Resources | Work | Text1 | Text2 | Text7 | Text11 | Text8 | Text12 | Text13 |
| --- | --- | --- | --- | --- | --- | --- | --- | --- | --- | --- | --- | --- | --- | --- | --- |
| 141 | SANE beam line and low power dump installation | 25d | 2008-09-02 | 2008-10-06 | 0d | finish no earlier than 2008-10-06 |  |  |  |  |  |  |  |  |  |
| 142 | Remove only necessary railing and pivot extensions to fit detector platform | 1d | 2008-09-02 | 2008-09-02 | 24d | start no earlier than 2008-09-02 | Hall C Tech's | 8h | ITHA Req'd | Req'd | 2 | Req'd |  |  |  |
| 143 | Install and align Cerenkov detector platform | 2d | 2008-09-02 | 2008-09-03 | 23d | start no earlier than 2008-09-02 | Hall C Tech's | 16h | ITHA Req'd |  | 1 |  |  |  |  |
| 144 | Crane in and bolt down support beam and post for lead shielding boxes | 1d | 2008-09-02 | 2008-09-02 | 24d | start no earlier than 2008-09-02 | Hall C Tech's | 8h | ITHA Req'd |  | 1 |  |  |  |  |
| 145 | Align and weld box beam security brackets to pivot acc. to drwg. | 1d | 2008-09-03 | 2008-09-03 | 23d | start no earlier than 2008-09-03 | Hall C Tech's | 8h | ITHA Req'd |  | 1 |  | Yes |  |  |
| 146 | RADCON support required | 1d | 2008-09-03 | 2008-09-03 | 23d | start no earlier than 2008-09-03 | RADCON | 8h | ITHA Req'd |  | 0 |  |  |  |  |
| 147 | Weld security brackets for lead ALU shield boxes (SOS side) to pivot | 1d | 2008-09-03 | 2008-09-03 | 23d | start no earlier than 2008-09-03 | Hall C Tech's | 8h | ITHA Req'd |  | 1 |  | Yes |  |  |
| 148 | RADCON support required | 1d | 2008-09-03 | 2008-09-03 | 23d | start no earlier than 2008-09-03 | RADCON | 8h | ITHA Req'd |  | 0 |  |  |  |  |
| 149 | Place and secure ALU shield boxes on box beam and bolt down | 1d | 2008-09-03 | 2008-09-03 | 23d | start no earlier than 2008-09-03 | Hall C Tech's | 8h | ITHA Req'd |  | 1 |  |  |  |  |
| 150 | Place and bolt down lead shield boxes on the SOS side | 1d | 2008-09-04 | 2008-09-04 | 22d | start no earlier than 2008-09-04 | Hall C Tech's | 8h | ITHA Req'd |  | 1 |  |  |  |  |
| 151 | Assemble target chamber exit beam line section and support | 1d | 2008-09-04 | 2008-09-04 | 22d | start no earlier than 2008-09-04 | Hall C Tech's | 8h | ITHA Req'd |  | 1 |  |  |  |  |
| 152 | Assemble He beam line unistrud support frame on the floor (dwg. 6750400050) | 3d | 2008-09-05 | 2008-09-09 | 19d | finish no earlier than 2008-09-09 | Hall C Tech's | 24h | THA Req'd |  | 2 |  |  |  |  |
| 153 | Layout anchor hole pattern for unistrud support frame | 1d | 2008-09-09 | 2008-09-09 | 19d | start no earlier than 2008-09-09 | Alignment Group | 8h | ITHA Req'd | Req'd | 1 |  |  |  |  |
| 154 | Lift up beam line support frame with 25' spreader bar and bolt to floor | 1d | 2008-09-10 | 2008-09-10 | 18d | start no earlier than 2008-09-10 | Hall C Tech's | 8h | ITHA Req'd |  | 2 |  |  | L Req'd |  |
| 155 | Roll out He beam line bag and hang onto frame with crane (dwg. 6750400050) | 1d | 2008-09-10 | 2008-09-10 | 18d | start no earlier than 2008-09-10 | Hall C Tech's | 8h | THA Req'd |  | 2 |  |  |  |  |
| 156 | Align and secure entire beam line | 1d | 2008-09-10 | 2008-09-10 | 18d | start no earlier than 2008-09-10 | Alignment Group / Hall C Tech's | 8h | ITHA Req'd |  | 1 |  |  |  |  |
| 157 | RADCON support required for work in beam dump area | 1d | 2008-09-10 | 2008-09-10 | 18d | start no earlier than 2008-09-10 | RADCON | 8h | ITHA Req'd | Req'd | 0 |  |  |  |  |
| 158 | Align Cerenkov detector mirrors (on the floor) | 3d | 2008-09-04 | 2008-09-08 | 20d | finish no earlier than 2008-09-08 | Experimenters | 24h | ITHA Req'd |  | 1 | Req'd |  |  |  |
| 159 | Place Cerenkov detector on platform | 1d | 2008-09-08 | 2008-09-08 | 20d | start no earlier than 2008-09-08 | Hall C Tech's | 8h | THA Req'd |  | 2 |  |  |  |  |
| 160 | Align Cerenkov detector and secure | 1d | 2008-09-09 | 2008-09-09 | 19d | start no earlier than 2008-09-09 | Alignment Group | 8h | ITHA Req'd |  | 1 |  |  |  |  |
| 161 | Connect all cables and detector gas system | 1d | 2008-09-10 | 2008-09-10 | 18d | start no earlier than 2008-09-10 | Hall C Tech's / Experim. | 8h | ITHA Req'd |  | 1 |  |  |  |  |
| 162 | Mount lucite detectors onto BIG CAL | 1d | 2008-09-09 | 2008-09-09 | 19d | start no earlier than 2008-09-09 | Hall C Tech's / Experim. | 8h | THA Req'd |  | 2 |  |  |  |  |
| 163 | Layout for 2nd beam line dump | 1d | 2008-09-09 | 2008-09-09 | 19d | start no earlier than 2008-09-09 | Hall C Tech's | 8h | ITHA Req'd |  | 0 |  |  |  |  |
| 164 | Crane in S4 steel blocks and place with 4 ton wall cane | 3d | 2008-09-09 | 2008-09-11 | 17d | finish no earlier than 2008-09-11 | Hall C Tech's | 24h | ITHA Req'd |  | 2 |  |  |  |  |
| 165 | Install He-supply pipe for He bag (from gas Bld to beam dump) | 2d | 2008-09-12 | 2008-09-15 | 15d | finish no earlier than 2008-09-15 | Hall C Tech's | 16h | ITHA Req'd |  | 1 |  |  |  |  |
| 166 | SOS disassembly | 8d? | 2008-09-16 | 2008-09-25 | 7d | finish no earlier than 2008-09-25 |  |  |  |  |  |  |  |  |  |
| 167 | Remove SOS detectors | 5d | 2008-09-19 | 2008-09-25 | 7d | finish no earlier than 2008-09-25 | Hall C Tech's / Experim. | 40h | THA Req'd |  | 2 |  |  |  |  |
| 168 | RADCON support required | 4d | 2008-09-22 | 2008-09-25 | 7d | start no earlier than 2008-09-22 | RADCON | 32h | ITHA Req'd |  | 0 |  |  |  |  |
| 169 | Place rail section to large angle and shim to level | 1d? | 2008-09-29 | 2008-09-29 | 5d | start no earlier than 2008-09-29 | Hall C Tech's | 8h | ITHA Req'd |  |  |  |  |  | Delayed |
| 170 | Place all toe-clamps | 1d? | 2008-09-29 | 2008-09-29 | 5d | start no earlier than 2008-09-29 | Hall C Tech's | 8h | ITHA Req'd |  |  |  |  |  | Delayed |
| 171 | shim level and align Rail, then torque down toe-clamps | 1d? | 2008-09-29 | 2008-09-29 | 5d | start no earlier than 2008-09-29 | Align. Group / Hall C Tech's | 8h | ITHA Req'd |  |  |  |  |  | Delayed |
| 172 | Move SOS to smaller angle | 1d? | 2008-09-29 | 2008-09-29 | 5d | start no earlier than 2008-09-29 | Hall C Tech's | 8h | ITHA Req'd |  |  |  |  |  | Delayed |
| 173 | Remove hydraulic fluid | 1d? | 2008-09-29 | 2008-09-29 | 5d | start no earlier than 2008-09-29 | Hall C Tech's | 8h | ITHA Req'd |  |  |  |  |  | Delayed |
| 174 | RADCON support required | 1d? | 2008-09-29 | 2008-09-29 | 5d | start no earlier than 2008-09-29 | RADCON | 8h | ITHA Req'd |  |  |  |  |  | Delayed |
| 175 | Remove hydraulic tank and pump | 1d? | 2008-09-29 | 2008-09-29 | 5d | start no earlier than 2008-09-29 | Hall C Tech's | 8h | ITHA Req'd |  |  |  |  |  | Delayed |
| 176 | RADCON support required | 1d? | 2008-09-29 | 2008-09-29 | 5d | start no earlier than 2008-09-29 | RADCON | 8h | ITHA Req'd |  |  |  |  |  | Delayed |
| 177 | Disconnect and remove A/C unit | 1d? | 2008-09-29 | 2008-09-29 | 5d | start no earlier than 2008-09-29 | Hall C Tech's / Electri. | 8h | ITHA Req'd |  |  |  |  |  | Delayed |
| 178 | RADCON support required | 1d? | 2008-09-29 | 2008-09-29 | 5d | start no earlier than 2008-09-29 | RADCON | 8h | ITHA Req'd |  |  |  |  |  | Delayed |
| 179 | Remove SOS doors | 1d? | 2008-09-29 | 2008-09-29 | 5d | start no earlier than 2008-09-29 | Hall C Tech's | 8h | ITHA Req'd |  |  |  |  |  | Delayed |
| 180 | RADCON support required | 1d? | 2008-09-29 | 2008-09-29 | 5d | start no earlier than 2008-09-29 | RADCON | 8h | ITHA Req'd |  |  |  |  |  | Delayed |
